# Inicio de Operaciones by Victor Falconi

Schedule from MS Project, 2010-12-13 to 2011-01-03, costs in $, A marks actual dates.
Nabors

## Calendars

- Estándar: Mon-Fri 09:00-13:00, 15:00-19:00; Sat-Sun off.

## Resources

| Resource | Rate |
| --- | --- |
| Mecanico Jr | 70 |
| Mecanico Sr | 100 |
| ATP | 70 |
| Electrico Jr | 75 |
| Eelctrico Sr | 100 |
| Sup. De Mantto. | 120 |
| Cia. De Limpieza - La Roca | 200 |
| Cia. De Inspección - Tuboscope | 187 |
| Soldador | 90 |
| API Certificador | 250 |

## Schedule

| ID | WBS | Task | Duration | Start | Finish | Predecessors | Complete | Remaining | Baseline 1 start | Baseline 1 finish | Total slack | Free slack | Resources | Work | Actual work | Cost | Actual cost |
| --- | --- | --- | --- | --- | --- | --- | --- | --- | --- | --- | --- | --- | --- | --- | --- | --- | --- |
| 1 | 1 | **Inicio de Operaciones - Equipos de Perforación** | 16d | 2010-12-13 A | 2011-01-03 |  | 8% | 14.8d | 2010-12-13 | 2011-01-03 | 0d |  |  | 824h | 50.4h | 108,912 | 8,433.6 |
| 2 | 1.1 | **Subestructura** | 14d | 2010-12-13 A | 2010-12-30 |  | 15% | 11.9d | 2010-12-13 | 2010-12-30 | 2d |  |  | 240h | 36h | 32,704 | 5,616 |
| 3 | 1.1.1 | Lavar subestructura | 6d | 2010-12-13 A | 2010-12-20 |  | 45% | 3.3d | 2010-12-13 | 2010-12-20 | 2d | 0d | Cia. De Limpieza - La Roca | 48h | 21.6h | 9,600 | 4,320 |
| 4 | 1.1.2 | Pintar subestructura | 4d | 2010-12-21 | 2010-12-24 | 3 |  |  | 2010-12-21 | 2010-12-24 | 2d | 0d | Cia. De Limpieza - La Roca | 32h |  | 6,400 |  |
| 5 | 1.1.3 | Inspeccionar MPI. | 4d | 2010-12-27 | 2010-12-30 | 4 |  |  | 2010-12-27 | 2010-12-30 | 2d |  | Cia. De Inspección - Tuboscope | 32h |  | 5,984 |  |
| 6 | 1.1.4 | Armar | 3d | 2010-12-13 | 2010-12-15 |  |  |  | 2010-12-13 | 2010-12-15 | 13d |  | Mecanico Jr | 24h |  | 1,680 |  |
| 7 | 1.1.5 | Cambiar Pines | 2d | 2010-12-13 | 2010-12-14 |  |  |  | 2010-12-13 | 2010-12-14 | 14d |  | ATP | 16h |  | 1,120 |  |
| 8 | 1.1.6 | Cambiar Viguetas | 6d | 2010-12-13 A | 2010-12-20 |  | 30% | 4.2d | 2010-12-13 | 2010-12-20 | 5d | 0d | Soldador | 48h | 14.4h | 4,320 | 1,296 |
| 9 | 1.1.7 | Cambiar Piso | 4d | 2010-12-21 | 2010-12-24 | 8 |  |  | 2010-12-21 | 2010-12-24 | 5d | 0d | Soldador | 32h |  | 2,880 |  |
| 10 | 1.1.8 | Cambiar Petatillo | 1d | 2010-12-27 | 2010-12-27 | 9 |  |  | 2010-12-27 | 2010-12-27 | 5d |  | Soldador | 8h |  | 720 |  |
| 11 | 1.2 | **Malacate** | 8d | 2010-12-13 A | 2010-12-22 |  | 14% | 6.89d | 2010-12-13 | 2010-12-22 | 8d |  |  | 104h | 14.4h | 18,008 | 2,817.6 |
| 12 | 1.2.1 | Limpiar | 3d | 2010-12-13 A | 2010-12-15 |  | 40% | 1.8d | 2010-12-13 | 2010-12-15 | 11d | 0d | Cia. De Limpieza - La Roca | 24h | 9.6h | 4,800 | 1,920 |
| 13 | 1.2.2 | Inspeccion Mécanica Estructural | 3d | 2010-12-13 A | 2010-12-15 |  | 20% | 2.4d | 2010-12-13 | 2010-12-15 | 8d | 0d | Cia. De Inspección - Tuboscope | 24h | 4.8h | 4,488 | 897.6 |
| 14 | 1.2.3 | Reparar Stufing Box | 2d | 2010-12-16 | 2010-12-17 | 13 |  |  | 2010-12-16 | 2010-12-17 | 8d | 0d | Mecanico Sr | 16h |  | 1,600 |  |
| 15 | 1.2.4 | Reparar Tolvas | 2d | 2010-12-16 | 2010-12-17 | 12 |  |  | 2010-12-16 | 2010-12-17 | 11d |  | Mecanico Jr | 16h |  | 1,120 |  |
| 16 | 1.2.5 | Certificación Instrumentacion Consola | 1d | 2010-12-20 | 2010-12-20 | 14 |  |  | 2010-12-20 | 2010-12-20 | 8d | 0d | API Certificador | 8h |  | 2,000 |  |
| 17 | 1.2.6 | Consola Perforador | 2d | 2010-12-21 | 2010-12-22 | 16 |  |  | 2010-12-21 | 2010-12-22 | 8d |  | API Certificador | 16h |  | 4,000 |  |
| 18 | 1.3 | **Corona** | 4d | 2010-12-13 | 2010-12-16 |  |  |  | 2010-12-13 | 2010-12-16 | 12d |  |  | 72h |  | 11,040 |  |
| 19 | 1.3.1 | Lavar | 1d | 2010-12-13 | 2010-12-13 |  |  |  | 2010-12-13 | 2010-12-13 | 13d |  | Cia. De Limpieza - La Roca | 8h |  | 1,600 |  |
| 20 | 1.3.2 | Desarmar | 2d | 2010-12-14 | 2010-12-15 | 19 |  |  | 2010-12-14 | 2010-12-15 | 13d |  | Mecanico Jr | 16h |  | 1,120 |  |
| 21 | 1.3.3 | Inspeccion y Certificación | 2d | 2010-12-13 | 2010-12-14 |  |  |  | 2010-12-13 | 2010-12-14 | 12d | 0d | API Certificador | 16h |  | 4,000 |  |
| 22 | 1.3.4 | Armar y Pintar | 2d | 2010-12-15 | 2010-12-16 | 21 |  |  | 2010-12-15 | 2010-12-16 | 12d |  | ATP; Cia. De Limpieza - La Roca | 32h |  | 4,320 |  |
| 23 | 1.4 | **Polea Viajera** | 5d | 2010-12-13 | 2010-12-17 |  |  |  | 2010-12-13 | 2010-12-17 | 11d |  |  | 80h |  | 13,200 |  |
| 24 | 1.4.1 | Lavar | 1d | 2010-12-13 | 2010-12-13 |  |  |  | 2010-12-13 | 2010-12-13 | 11d | 0d | Cia. De Limpieza - La Roca; Sup. De Mantto.; API Certificador | 24h |  | 4,560 |  |
| 25 | 1.4.2 | Desarmar | 1d | 2010-12-14 | 2010-12-14 | 24 |  |  | 2010-12-14 | 2010-12-14 | 11d | 0d | Mecanico Jr | 8h |  | 560 |  |
| 26 | 1.4.3 | Inspeccionar y Certificar | 2d | 2010-12-15 | 2010-12-16 | 25 |  |  | 2010-12-15 | 2010-12-16 | 11d | 0d | Sup. De Mantto.; API Certificador | 32h |  | 5,920 |  |
| 27 | 1.4.4 | Armar y Pintar | 1d | 2010-12-17 | 2010-12-17 | 26 |  |  | 2010-12-17 | 2010-12-17 | 11d |  | Mecanico Jr; Cia. De Limpieza - La Roca | 16h |  | 2,160 |  |

| ID | WBS | Task | Duration | Start | Finish | Predecessors | Baseline 1 start | Baseline 1 finish | Total slack | Free slack | Resources | Work | Cost |
| --- | --- | --- | --- | --- | --- | --- | --- | --- | --- | --- | --- | --- | --- |
| 28 | 1.5 | **Bombas de Lodo** | 6d | 2010-12-13 | 2010-12-20 |  | 2010-12-13 | 2010-12-20 | 10d |  |  | 104h | 13,840 |
| 29 | 1.5.1 | Desarrollar y revisar parte mecanica | 3d | 2010-12-13 | 2010-12-15 |  | 2010-12-13 | 2010-12-15 | 10d | 0d | Sup. De Mantto.; Mecanico Sr | 48h | 5,280 |
| 30 | 1.5.2 | Inspeccionar y certificar | 3d | 2010-12-16 | 2010-12-20 | 29 | 2010-12-16 | 2010-12-20 | 10d |  | API Certificador | 24h | 6,000 |
| 31 | 1.5.3 | Revisar y cambiar valvulas en caso de requerirse | 1d | 2010-12-16 | 2010-12-16 | 29 | 2010-12-16 | 2010-12-16 | 12d |  | Mecanico Jr | 8h | 560 |
| 32 | 1.5.4 | Cambiar camisas, pistones, valvulas y asientos | 1d | 2010-12-13 | 2010-12-13 |  | 2010-12-13 | 2010-12-13 | 13d | 0d | Mecanico Jr | 8h | 560 |
| 33 | 1.5.5 | Cambiar modulos soldados | 2d | 2010-12-14 | 2010-12-15 | 32 | 2010-12-14 | 2010-12-15 | 13d |  | Soldador | 16h | 1,440 |
| 34 | 1.6 | **Instalar Bomba No. 3** | 16d | 2010-12-13 | 2011-01-03 |  | 2010-12-13 | 2011-01-03 | 0d |  |  | 224h | 20,120 |
| 35 | 1.6.1 | Cableado Electrico y lineas de succión descargada | 1d | 2010-12-13 | 2010-12-13 |  | 2010-12-13 | 2010-12-13 | 0d |  | Electrico Jr; Soldador | 16h | 1,320 |
| 36 | 1.6.2 | Revisar mangueras y cambiar si se requiera | 1d | 2010-12-14 | 2010-12-14 | 35 | 2010-12-14 | 2010-12-14 | 12d | 0d | Mecanico Jr | 8h | 560 |
| 37 | 1.6.3 | Manifold de Succión | 2d | 2010-12-15 | 2010-12-16 | 36 | 2010-12-15 | 2010-12-16 | 12d |  | Soldador; Sup. De Mantto. | 32h | 3,360 |
| 38 | 1.6.4 | Revisar y cambiar de valvulas si se requiere | 2d | 2010-12-14 | 2010-12-15 | 35 | 2010-12-14 | 2010-12-15 | 0d |  | Soldador; Mecanico Jr | 32h | 2,560 |
| 39 | 1.6.5 | Revisar centrifuga, reparar o cambiar | 2d | 2010-12-16 | 2010-12-17 | 38 | 2010-12-16 | 2010-12-17 | 0d |  | Mecanico Sr; Mecanico Jr | 32h | 2,720 |
| 40 | 1.6.6 | Fabricar Lineas para instalar bomba no. 3 | 3d | 2010-12-20 | 2010-12-22 | 39 | 2010-12-20 | 2010-12-22 | 0d |  | Soldador | 24h | 2,160 |
| 41 | 1.6.7 | Instalar valvulas de seguridad para las 3 bombas | 2d | 2010-12-23 | 2010-12-24 | 40 | 2010-12-23 | 2010-12-24 | 0d |  | Mecanico Jr | 16h | 1,120 |
| 42 | 1.6.8 | Modificar lineas de descarga de bombas 1 y 2 | 2d | 2010-12-27 | 2010-12-28 | 41 | 2010-12-27 | 2010-12-28 | 0d |  | Soldador; Sup. De Mantto. | 32h | 3,360 |
| 43 | 1.6.9 | Fabricar linea de descarga a bomba 3 | 3d | 2010-12-29 | 2010-12-31 | 42 | 2010-12-29 | 2010-12-31 | 0d |  | Soldador | 24h | 2,160 |
| 44 | 1.6.10 | Reparar o instalar Dampener en lineas de succión de 3 bombas | 1d | 2011-01-03 | 2011-01-03 | 43 | 2011-01-03 | 2011-01-03 | 0d |  | Mecanico Sr | 8h | 800 |
